# سونوگرافی

Schedule from MS Project, 2023-02-08 to 2024-09-12, costs in تومان.

## Calendars

- Standard: Mon-Fri 08:00-12:00, 13:00-17:00; Sat-Sun off.

## Resources

| Resource |
| --- |
| 2 |
| محقق |
| عضو هیات علمی |
| کارشناس تولید |
| مسئول فنی |

## Schedule

| ID | WBS | Task | Type | Duration | Start | Finish | Predecessors | Total slack | Resources | Work | Cost |
| --- | --- | --- | --- | --- | --- | --- | --- | --- | --- | --- | --- |
| 1 | 1 | **پروژه ژل سونوگرافی** |  | 417d | 2023-02-08 | 2024-09-12 |  | 0d |  | 7248h | 1,597,500,000 |
| 2 | 1.1 | **فاز مطالعاتی** |  | 30d | 2023-02-08 | 2023-03-21 |  | 0d |  | 800h | 25,000,000 |
| 3 | 1.1.1 | بررسی اولیه متون علمی مربوط به کاربرد ژل سونوگرافی | manual | 10d | 2023-02-08 | 2023-02-21 |  |  | عضو هیات علمی; محقق | 160h | 5,000,000 |
| 4 | 1.1.2 | بررسی مجوزهای لازم برای تجاری سازی ژل‌های سونوگرافی | manual | 10d | 2023-02-22 | 2023-03-07 |  |  | عضو هیات علمی; محقق | 160h | 5,000,000 |
| 5 | 1.1.3 | مطالعه مواد اولیه مورد نیاز و آنالیزهای مورد نیاز | manual | 10d | 2023-02-22 | 2023-03-07 |  |  | عضو هیات علمی; محقق | 160h | 5,000,000 |
| 6 | 1.1.4 | مطالعه قیمت در بازار و سایر رقبا و کیفیت محصول و بسته بندی | manual | 15d | 2023-02-22 | 2023-03-14 |  |  | عضو هیات علمی; محقق | 240h | 5,000,000 |
| 7 | 1.1.5 | جمع بندی و هدف گذاری | manual | 5d | 2023-03-15 | 2023-03-21 |  |  | عضو هیات علمی; محقق | 80h | 5,000,000 |
| 8 | 1.2 | **راه اندازی خط تولید** |  | 106d | 2023-03-15 | 2023-08-09 |  | 0d |  | 2936h | 157,500,000 |
| 9 | 1.2.1 | **فرمولاسیون** |  | 51d | 2023-03-22 | 2023-05-31 |  | 0d |  | 656h | 25,000,000 |
| 10 | 1.2.1.1 | خرید و تهیه مواد اولیه | manual | 14d | 2023-03-22 | 2023-04-10 |  |  | عضو هیات علمی; محقق | 224h | 15,000,000 |
| 11 | 1.2.1.2 | تهیه نمونه بر اساس طراحی آزمایش و بهینه سازی قیمت کارایی | manual | 20d | 2023-04-11 | 2023-05-08 |  |  | عضو هیات علمی; محقق | 320h | 5,000,000 |
| 12 | 1.2.1.3 | انتخاب نمونه های منتخب | manual | 7d | 2023-05-23 | 2023-05-31 |  |  | عضو هیات علمی; محقق | 112h | 5,000,000 |
| 13 | 1.2.2 | **تست‌های آزمایشگاهی** |  | 15d | 2023-06-01 | 2023-06-21 |  | 0d |  | 480h | 3,000,000 |
| 14 | 1.2.2.1 | بررسی خواص فیزیکی و شیمیایی | manual | 15d | 2023-06-01 | 2023-06-21 | 12 |  | عضو هیات علمی; محقق | 240h | 1,000,000 |
| 15 | 1.2.2.2 | بررسی کارایی و شفافیت تحت اولتراسونیک | manual | 15d | 2023-06-01 | 2023-06-21 | 12 |  | عضو هیات علمی; محقق | 240h | 2,000,000 |
| 16 | 1.2.3 | **آنالیزهای پایداری و زیست سازگاری** |  | 35d | 2023-06-22 | 2023-08-09 |  | 0d |  | 448h | 20,000,000 |
| 17 | 1.2.3.1 | آنالیزهای سمیت سلولی | manual | 14d | 2023-06-22 | 2023-07-11 | 15 |  | عضو هیات علمی; محقق | 224h | 15,000,000 |
| 18 | 1.2.3.2 | آنالیزهای حساسیت زایی | manual | 14d | 2023-07-21 | 2023-08-09 | 17 |  | عضو هیات علمی; محقق | 224h | 5,000,000 |
| 19 | 1.2.4 | **طراحی و تهیه بسته بندی** |  | 45d | 2023-03-15 | 2023-05-16 |  | 0d |  | 832h | 59,500,000 |
| 20 | 1.2.4.1 | ساخت قالب ظروف 5 لیتری و طراحی ظروف 1 لیتری و 260 سی سی | manual | 45d | 2023-03-15 | 2023-05-16 | 6 |  | کارشناس تولید; محقق | 720h | 59,000,000 |
| 21 | 1.2.4.2 | بررسی قیمت و کیفیت تولیدکنندگان و تدوین لیست تامین کنندگان | manual | 14d | 2023-03-15 | 2023-04-03 | 6 |  | کارشناس تولید | 112h | 500,000 |
| 22 | 1.2.5 | **تکرار پذیری تولید و تدوین شرایط کنترل کیفی** |  | 30d | 2023-06-22 | 2023-08-02 |  | 0d |  | 352h | 35,000,000 |
| 23 | 1.2.5.1 | تدوین روش‌های اجرایی و تست‌های کنترل کیفی حین تولید | manual | 30d | 2023-06-22 | 2023-08-02 | 15 |  | کارشناس تولید | 240h | 35,000,000 |
| 24 | 1.2.5.2 | کنترل کیفی محصول نهایی | manual | 14d | 2023-06-22 | 2023-07-11 | 15 |  | مسئول فنی | 112h |  |
| 25 | 1.2.6 | اخذ تاییدیه مراکز سونوگرافی و پزشکان معتمد | manual | 21d | 2023-05-17 | 2023-06-14 | 20 |  | مسئول فنی | 168h | 15,000,000 |

| ID | WBS | Task | Type | Duration | Start | Finish | Predecessors | Total slack | Resources | Work | Cost |
| --- | --- | --- | --- | --- | --- | --- | --- | --- | --- | --- | --- |
| 26 | 1.3 | **تولید انبوه و تجاری سازی** |  | 387d | 2023-03-22 | 2024-09-12 |  | 0d |  | 3512h | 1,415,000,000 |
| 27 | 1.3.1 | **طراحی فرآیند تولید، خرید تجهیزات** |  | 111d | 2023-06-15 | 2023-11-16 |  | 0d |  | 648h | 189,000,000 |
| 28 | 1.3.1.1 | تعیین ظرفیت تولید و فرآیندها و پیگیری تولید کنندگان معتبر | manual | 21d | 2023-06-15 | 2023-07-13 | 25 |  | کارشناس تولید | 168h |  |
| 29 | 1.3.1.2 | سفارش ساخت و خرید تجهیزات | manual | 60d | 2023-06-15 | 2023-09-06 | 25 |  | کارشناس تولید | 480h | 150,000,000 |
| 30 | 1.3.1.3 | پایپینگ و نصب تجهیزات | manual | 21d | 2023-10-19 | 2023-11-16 | 29 |  |  |  | 39,000,000 |
| 31 | 1.3.2 | **استقرار ایزو 13485** |  | 90d | 2023-11-17 | 2024-03-21 |  | 0d |  | 720h | 100,000,000 |
| 32 | 1.3.2.1 | عقد قرارداد با شرکت مشاور ایزو 13485 | manual | 30d | 2023-11-17 | 2023-12-28 | 30 |  | مسئول فنی | 240h | 35,000,000 |
| 33 | 1.3.2.2 | تهیه اسناد و رفع عدم انطباق های موجود سالن تولید | manual | 30d | 2023-12-29 | 2024-02-08 | 32 |  | مسئول فنی | 240h | 2,000,000 |
| 34 | 1.3.2.3 | سپری کردن ممیزی های ایزو و اخذ ایزو13485 | manual | 30d | 2024-02-09 | 2024-03-21 | 33 |  | مسئول فنی | 240h | 63,000,000 |
| 35 | 1.3.3 | **اخذ مجوز اداره کل تجهیزات پزشکی** |  | 332d | 2023-03-22 | 2024-06-27 |  | 0d |  | 800h | 34,000,000 |
| 36 | 1.3.3.1 | ثبت برند سافت ژل | manual | 30d | 2023-03-22 | 2023-05-02 | 7 |  | مسئول فنی | 240h | 2,000,000 |
| 37 | 1.3.3.2 | بارگذاری اسناد لازم برای معاونت تجهیزات پزشکی | manual | 30d | 2024-03-22 | 2024-05-02 | 34 |  | مسئول فنی | 240h |  |
| 38 | 1.3.3.3 | برگزاری ممیزی غذا و دارو، رفع عدم انطباق ها و اخذ پروانه تولید | manual | 40d | 2024-05-03 | 2024-06-27 | 37 |  | مسئول فنی | 320h | 32,000,000 |
| 39 | 1.3.4 | **راه اندازی خط تولید و بهینه سازی** |  | 14d | 2024-07-26 | 2024-08-14 |  | 0d |  | 1120h | 1,092,000,000 |
| 40 | 1.3.4.1 | راه اندازی سیستم آب دیونیزه | manual | 14d | 2024-07-26 | 2024-08-14 | 38 |  | کارشناس تولید; عضو هیات علمی; محقق; مسئول فنی | 448h | 79,000,000 |
| 41 | 1.3.4.2 | خرید و تهیه مواد اولیه برای تولید 100 هزار لیتر | manual | 14d | 2024-07-26 | 2024-08-14 | 38 |  | کارشناس تولید; عضو هیات علمی; محقق; مسئول فنی | 448h | 940,000,000 |
| 42 | 1.3.4.3 | تدوین و اجرای نظام انبارداری و سایر موارد تولید | manual | 7d | 2024-07-26 | 2024-08-05 | 38 |  | کارشناس تولید; عضو هیات علمی; محقق; مسئول فنی | 224h | 73,000,000 |
| 43 | 1.3.5 | **تجاری سازی و ارائه محصول با برند سافت ژل** |  | 28d | 2024-08-06 | 2024-09-12 |  | 0d |  | 224h |  |
| 44 | 1.3.5.1 | استراتژی فروش و قیمت گذاری | manual | 14d | 2024-08-06 | 2024-08-23 | 42 |  | مسئول فنی | 112h |  |
| 45 | 1.3.5.2 | فروش | manual | 14d | 2024-08-26 | 2024-09-12 | 44 |  | مسئول فنی | 112h |  |
