# سونوگرافی

Schedule from MS Project, 2023-02-08 to 2024-10-29, costs in تومان.

## Calendars

- Standard: Mon-Fri 08:00-12:00, 13:00-17:00; Sat-Sun off.

## Resources

| Resource |
| --- |
| 2 |
| محقق |
| عضو هیات علمی |
| کارشناس تولید |
| مسئول فنی |

## Schedule

| ID | WBS | Task | Type | Duration | Start | Finish | Predecessors | Total slack | Resources | Work | Cost |
| --- | --- | --- | --- | --- | --- | --- | --- | --- | --- | --- | --- |
| 1 | 1 | **ژل پلاگ پلیمری** |  | 450d | 2023-02-08 | 2024-10-29 |  | 0d |  | 22160h | 917,500,000 |
| 2 | 1.1 | **فاز مطالعاتی** |  | 190d | 2023-02-08 | 2023-10-31 |  | 0d |  | 5520h | 110,000,000 |
| 3 | 1.1.1 | بررسی اولیه و اعتبارسنجی موضوع طرح | manual | 15d | 2023-02-08 | 2023-02-28 |  |  | عضو هیات علمی; محقق | 240h | 5,000,000 |
| 4 | 1.1.2 | جستجوی مقالات و پتنت ها در حوزه مورد مطالعه | manual | 15d | 2023-02-22 | 2023-03-14 |  |  | عضو هیات علمی; محقق | 240h | 10,000,000 |
| 5 | 1.1.3 | مطالعه موادی و مفاهیم اولیه | manual | 60d | 2023-03-15 | 2023-06-06 | 4 |  | عضو هیات علمی; محقق | 960h | 15,000,000 |
| 6 | 1.1.4 | مطالعه فرآیندها و شرایط میدانی بندش موقت چاه | manual | 60d | 2023-06-07 | 2023-08-29 | 5 |  | عضو هیات علمی; محقق | 960h | 10,000,000 |
| 7 | 1.1.5 | بررسی روش های مختلف بندش موقت چاه و محاسبات اقتصادی | manual | 30d | 2023-08-30 | 2023-10-10 | 6 |  | عضو هیات علمی; محقق | 480h | 10,000,000 |
| 8 | 1.1.6 | بررسی مواد اولیه مورد استفاده در تهیه ژل پلاگ در مراجع علمی و تعیین قیمت هر کدام | manual | 30d | 2023-03-15 | 2023-04-25 | 4 |  | عضو هیات علمی; محقق | 480h | 5,000,000 |
| 9 | 1.1.7 | یافتن تجربیات قبلی در کشور در زمینه استفاده از روش انسداد موقت چاه با ژل پلیمری | manual | 30d | 2023-03-15 | 2023-04-25 | 4 |  | عضو هیات علمی; محقق | 480h | 5,000,000 |
| 10 | 1.1.8 | شناسایی افراد با تجربه در صنعت حفاری و نفت و معرفی موضوع و دریافت نظرات و پیشنهادات | manual | 90d | 2023-03-15 | 2023-07-18 | 4 |  | عضو هیات علمی; محقق | 1440h | 30,000,000 |
| 11 | 1.1.9 | جمع بندی و تعیین مسیر آزمایشگاهی پیش رو | manual | 15d | 2023-10-11 | 2023-10-31 | 6, 7 |  | عضو هیات علمی; محقق | 240h | 20,000,000 |
| 12 | 1.2 | **فاز آزمایشگاهی و فرمولاسیون** |  | 260d | 2023-11-01 | 2024-10-29 |  | 0d | عضو هیات علمی; محقق | 9920h | 357,500,000 |
| 13 | 1.2.1 | تهیه مواد و امکانات لازم | manual | 30d | 2023-11-01 | 2023-12-12 | 11 |  | عضو هیات علمی; محقق | 480h | 25,000,000 |
| 14 | 1.2.2 | بررسی اثر غلظت عامل شبکه ای کننده بر استحکام ژل | manual | 20d | 2023-12-13 | 2024-01-09 |  |  | عضو هیات علمی; محقق | 320h | 16,500,000 |
| 15 | 1.2.3 | بررسی اثر عوامل مختلف دما، فشار و اسیدیته بر رفتار ژل | manual | 20d | 2023-12-13 | 2024-01-09 |  |  | عضو هیات علمی; محقق | 320h | 23,000,000 |
| 16 | 1.2.4 | مهندسی بندش و شکست ژل | manual | 20d | 2023-12-13 | 2024-01-09 |  |  | عضو هیات علمی; محقق | 320h | 13,000,000 |
| 17 | 1.2.5 | طراحی و ساخت سیستم تست پایلوت ژل | manual | 90d | 2024-01-10 | 2024-05-14 |  |  | عضو هیات علمی; محقق | 1440h | 180,000,000 |
| 18 | 1.2.6 | استانداردسازی خواص ژل متناسب با خواص اعلامی مورد نظر کارفرما | manual | 90d | 2024-05-15 | 2024-09-17 |  |  | عضو هیات علمی; محقق | 1440h | 50,000,000 |
| 19 | 1.2.7 | جمع بندی فاز آزمایشگاهی و فرمولاسیون | manual | 30d | 2024-09-18 | 2024-10-29 |  |  | عضو هیات علمی; محقق | 480h | 20,000,000 |
| 20 | 1.2.8 | انتشار ثبت اختراع طرح | manual | 60d | 2023-12-13 | 2024-03-05 |  |  | عضو هیات علمی; محقق | 960h | 30,000,000 |
| 21 | 1.3 | **فاز تست میدانی** |  | 210d | 2023-11-01 | 2024-08-20 |  | 0d | عضو هیات علمی; محقق | 6720h | 450,000,000 |
| 22 | 1.3.1 | رایزنی با شرکت های حفاری و نفتی برای انجام تست میدانی | manual | 90d | 2023-11-01 | 2024-03-05 | 11 |  | عضو هیات علمی; محقق | 1440h | 50,000,000 |
| 23 | 1.3.2 | تست میدانی | manual | 90d | 2024-03-06 | 2024-07-09 | 22 |  | عضو هیات علمی; محقق | 1440h | 350,000,000 |
| 24 | 1.3.3 | بهینه سازی و رفع کاستی های احتمالی | manual | 30d | 2024-07-10 | 2024-08-20 | 23 |  | عضو هیات علمی; محقق | 480h | 50,000,000 |
